# 260202_planning_DCE

Schedule from MS Project, 2025-12-15 to 2026-12-18, 7 hours a day.

## Calendars

- Standard: Mon-Fri 09:00-12:00, 14:00-18:00; Sat-Sun off.

## Resources

| Resource |
| --- |
| PUCHER |
| Service Logistique |
| RANNOU |
| BODIN |
| Titulaires marchés travaux |
| Fournisseur via UGAP |
| BOULO |
| Direction Filière Personnes Agées |
| PERROT |
| GRUSKOVNJAK |
| UGAP |
| Direction Achats |
| MOREAU |

## Schedule

| ID | WBS | Task | Type | Duration | Start | Finish | Predecessors | Total slack | Free slack | Constraint |
| --- | --- | --- | --- | --- | --- | --- | --- | --- | --- | --- |
| 1 | 1 | **Travaux JA : phase conception** |  | 111d | 2025-12-15 | 2026-05-18 |  | 0d |  |  |
| 2 | 1.1 | Reprise du dossier JA | milestone, manual | 1d | 2025-12-15 | 2025-12-15 |  |  |  |  |
| 3 | 1.2 | **Prestations de travaux** |  | 68d | 2025-12-16 | 2026-03-19 |  | 43d |  |  |
| 4 | 1.2.1 | Rédaction des CCTP, planning previsionnel |  | 31d | 2025-12-16 | 2026-01-27 | 2 | 226d | 0d |  |
| 5 | 1.2.2 | Rédaction des pièces administratives |  | 31d | 2025-12-16 | 2026-01-27 | 2 | 226d | 0d |  |
| 6 | 1.2.3 | Relecture de l'ensemble des docs, finalisation |  | 7d | 2026-01-28 | 2026-02-06 | 4, 5, 7SF | 226d |  | start no earlier than 2026-01-28 |
| 7 | 1.2.4 | Publication AAPC | milestone | 1d | 2026-02-06 | 2026-02-06 |  | 225d | 0d | start no earlier than 2026-02-06 |
| 8 | 1.2.5 | Visite obligatoire de site par les candidats : 1e proposition de creneau | milestone, manual | 1d | 2026-02-13 | 2026-02-13 |  |  |  |  |
| 9 | 1.2.6 | Visite obligatoire de site par les candidats : 2e proposition de creneau | milestone, manual | 1d | 2026-02-18 | 2026-02-18 |  |  |  |  |
| 10 | 1.2.7 | Remise des offres | milestone, manual | 1d | 2026-02-27 | 2026-02-27 |  |  |  |  |
| 11 | 1.2.8 | Ouverture des plis |  | 1d | 2026-02-27 | 2026-02-27 | 10SS | 0d |  |  |
| 12 | 1.2.9 | Analyse technique / financière des offres |  | 14d | 2026-03-02 | 2026-03-19 | 11 | 0d |  |  |
| 13 | 1.2.10 | Analyse administrative des candidatures |  | 14d | 2026-03-02 | 2026-03-19 | 11 | 0d |  |  |
| 14 | 1.2.11 | Lettre de rejet adressée aux candidats non retenus | milestone | 1d | 2026-03-19 | 2026-03-19 | 12FF, 13FF | 0d |  |  |
| 15 | 1.3 | Notification du marché de travaux | milestone | 1d | 2026-03-20 | 2026-03-20 | 14 | 0d |  |  |
| 16 | 1.4 | **Prestations intellectuelles** |  | 52d | 2025-12-16 | 2026-02-25 |  | 212d |  |  |
| 17 | 1.4.1 | Rédaction des descriptifs techniques CSPS CT SSI |  | 35d | 2025-12-16 | 2026-02-02 | 2 | 217d | 5d | finish no earlier than 2026-01-16 |
| 18 | 1.4.2 | Envoi des projets de marchés | milestone | 1d | 2026-02-10 | 2026-02-10 | 17 | 212d | 0d | start no earlier than 2026-02-10 |
| 19 | 1.4.3 | Remise des offres |  | 5d | 2026-02-11 | 2026-02-17 | 18 | 212d | 0d |  |
| 20 | 1.4.4 | Analyse technique / financière des offres |  | 5d | 2026-02-18 | 2026-02-24 | 19 | 212d | 0d |  |
| 21 | 1.4.5 | Analyse administrative des candidatures |  | 5d | 2026-02-18 | 2026-02-24 | 19 | 212d | 0d |  |
| 22 | 1.4.6 | Notification des marchés CSPS CT SSI | milestone | 1d | 2026-02-25 | 2026-02-25 | 20, 21 | 212d |  |  |
| 23 | 1.5 | **Achats** |  | 61d | 2026-02-23 | 2026-05-18 |  | 141d |  |  |
| 24 | 1.5.1 | Commande UGAP des armoires | milestone | 1d | 2026-02-23 | 2026-02-23 |  | 141d | 0d | start no earlier than 2026-02-23 |
| 25 | 1.5.2 | Fabrication des armoires |  | 60d | 2026-02-24 | 2026-05-18 | 24 | 141d | 21d |  |
| 26 | 1.5.3 | Commande UGAP des rails leve-malades | milestone | 1d | 2026-02-23 | 2026-02-23 |  | 176d | 0d | start no earlier than 2026-02-23 |
| 27 | 1.5.4 | Fabrication des rails leve-malades |  | 25d | 2026-02-24 | 2026-03-30 | 26 | 176d | 56d |  |

| ID | WBS | Task | Type | Duration | Start | Finish | Predecessors | Total slack | Free slack | Resources | Work |
| --- | --- | --- | --- | --- | --- | --- | --- | --- | --- | --- | --- |
| 28 | 2 | **Travaux JA : phase réalisation** |  | 205d | 2026-03-09 | 2026-12-18 |  | 0d |  |  | 15610h |
| 29 | 2.1 | Ordre de service de démarrage TF dont 2 semaines de préparation | milestone | 1d | 2026-03-23 | 2026-03-23 | 15 | 0d |  |  |  |
| 30 | 2.2 | Notification d'affermissement de la TO n°3 | milestone | 1d | 2026-03-23 | 2026-03-23 | 15 | 194d |  |  |  |
| 31 | 2.3 | Ordre de service de démarrage de la phase de preparation TO n°3 | milestone | 1d | 2026-03-23 | 2026-03-23 | 15 | 0d |  |  |  |
| 32 | 2.4 | Notification d'affermissement de la TO n°4 | milestone | 1d | 2026-03-23 | 2026-03-23 | 15 | 194d |  |  |  |
| 33 | 2.5 | Ordre de service de démarrage de la phase de preparation TO n°4 | milestone | 1d | 2026-03-23 | 2026-03-23 | 15 | 194d |  |  |  |
| 34 | 2.6 | **Tranche ferme = R+1** |  | 85d | 2026-03-09 | 2026-07-03 |  | 10d |  |  | 2877h |
| 35 | 2.6.1 | **Préparation des travaux** |  | 20d | 2026-03-09 | 2026-04-06 |  | 10d |  |  | 70h |
| 36 | 2.6.1.1 | Dépose d'équipements techniques avant travaux pour le R+1 |  | 20d | 2026-03-09 | 2026-04-06 | 43SF | 185d |  |  |  |
| 37 | 2.6.1.2 | Enlèvement du mobilier actuel et stockage en vue de la re-installation |  | 20d | 2026-03-09 | 2026-04-06 | 43SF | 185d |  |  |  |
| 38 | 2.6.1.3 | Préparation du chantier par les titulaires |  | 10d | 2026-03-23 | 2026-04-03 | 29SS | 0d |  | Titulaires marchés travaux | 70h |
| 39 | 2.6.1.4 | Préparation du chantier par le GHRE |  | 10d | 2026-03-23 | 2026-04-06 | 43SF | 185d |  |  |  |
| 40 | 2.6.1.5 | Faire déplacer le(s) véhicule(s) éventuellement stationnés ds le garage |  | 5d | 2026-03-30 | 2026-04-06 | 43SF | 185d |  |  |  |
| 41 | 2.6.1.6 | Dégager l'accès vers les 4 ascenseurs |  | 5d | 2026-03-30 | 2026-04-06 | 43SF | 185d |  |  |  |
| 42 | 2.6.2 | **Travaux** |  | 65d | 2026-04-06 | 2026-07-03 |  | 0d |  |  | 2807h |
| 43 | 2.6.2.1 | **Travaux réalisés par les titulaires** |  | 50d | 2026-04-06 | 2026-06-12 |  | 0d |  | Titulaires marchés travaux | 2800h |
| 44 | 2.6.2.1.1 | Lot n°1 : démolition / gros oeuvre |  | 50d | 2026-04-06 | 2026-06-12 | 38 | 0d |  | Titulaires marchés travaux | 350h |
| 45 | 2.6.2.1.2 | Lot n°2 : cloisonnement / faux plafond |  | 50d | 2026-04-06 | 2026-06-12 | 38 | 0d |  | Titulaires marchés travaux | 350h |
| 46 | 2.6.2.1.3 | Lot n°3 : menuiseries intérieures |  | 50d | 2026-04-06 | 2026-06-12 | 38 | 0d |  | Titulaires marchés travaux | 350h |
| 47 | 2.6.2.1.4 | Lot n°4 : électricité Cfa / CFO / SSI |  | 50d | 2026-04-06 | 2026-06-12 | 38 | 0d |  | Titulaires marchés travaux | 350h |
| 48 | 2.6.2.1.5 | Lot n°5 : plomberie / chauffage / ventilation |  | 50d | 2026-04-06 | 2026-06-12 | 38 | 0d |  | Titulaires marchés travaux | 350h |
| 49 | 2.6.2.1.6 | Lot n°6 : travaux de revêtements sols et murs |  | 50d | 2026-04-06 | 2026-06-12 | 38 | 0d |  | Titulaires marchés travaux | 350h |
| 50 | 2.6.2.1.7 | Lot n°7 : travaux de peinture / nettoyage |  | 50d | 2026-04-06 | 2026-06-12 | 38 | 0d |  | Titulaires marchés travaux | 350h |
| 51 | 2.6.2.2 | Nettoyage de fin de chantier |  | 1d | 2026-06-15 | 2026-06-15 | 43 | 120d | 0d | Titulaires marchés travaux | 7h |
| 52 | 2.6.2.3 | Réception partielle prononcée par le GHRE | milestone | 1d | 2026-06-16 | 2026-06-16 | 51 | 120d | 0d |  |  |
| 53 | 2.6.2.4 | Livraison et installation des rails leve-malade |  | 5d | 2026-06-17 | 2026-06-23 | 52, 27 | 120d | 0d |  |  |
| 54 | 2.6.2.5 | Livraison et montage de 10 armoires neuves (1/2 journee de travail réel, a caler finement sur la periode ensuite) |  | 5d | 2026-06-17 | 2026-06-23 | 52, 25 | 120d | 0d |  |  |
| 55 | 2.6.2.6 | Bio-nettoyage réalisé par le GHRE |  | 1d | 2026-06-24 | 2026-06-24 | 53, 54 | 120d | 0d |  |  |
| 56 | 2.6.2.7 | Repose des équipements R+1 |  | 5d | 2026-06-25 | 2026-07-01 | 55 | 120d | 0d |  |  |
| 57 | 2.6.2.8 | Remettre le mobilier conservé : fauteuils, lits, chevets |  | 5d | 2026-06-25 | 2026-07-01 | 55 | 120d | 0d |  |  |
| 58 | 2.6.2.9 | Bio-nettoyage réalisé par le GHRE |  | 1d | 2026-07-02 | 2026-07-02 | 56, 57 | 120d | 0d |  |  |
| 59 | 2.6.2.10 | Zone de travaux restituée à l'EPHAD pour l'hébergement + soins | milestone | 1d | 2026-07-03 | 2026-07-03 | 58, 55 | 120d |  |  |  |
| 60 | 2.7 | Notification d'affermissement de la TO n°1 | milestone | 1d | 2026-05-15 | 2026-05-18 | 71SF-20d | 134d | 0d |  |  |
| 61 | 2.8 | Ordre de service de démarrage TO n°1 dont 2 semaines de préparation | milestone | 1d | 2026-06-01 | 2026-06-01 | 60FS+10d | 134d | 0d |  |  |

| ID | WBS | Task | Type | Duration | Start | Finish | Predecessors | Total slack | Free slack | Constraint | Resources | Work |
| --- | --- | --- | --- | --- | --- | --- | --- | --- | --- | --- | --- | --- |
| 62 | 2.9 | **Tranche optionnelle n°1 = R+2** |  | 105d | 2026-05-18 | 2026-10-09 |  | 20d |  |  |  | 4179h |
| 63 | 2.9.1 | **Préparation des travaux** |  | 21d | 2026-05-18 | 2026-06-15 |  | 134d |  |  |  | 70h |
| 64 | 2.9.1.1 | Dépose d'équipements techniques avant travaux pour le R+2 |  | 20d | 2026-05-18 | 2026-06-15 | 71SF | 135d |  |  |  |  |
| 65 | 2.9.1.2 | Enlèvement du mobilier actuel et stockage en vue de la re-installation |  | 20d | 2026-05-18 | 2026-06-15 | 71SF | 135d |  |  |  |  |
| 66 | 2.9.1.3 | Préparation du chantier par le titulaire |  | 10d | 2026-06-02 | 2026-06-15 | 61 | 134d |  |  | Titulaires marchés travaux | 70h |
| 67 | 2.9.1.4 | Préparation du chantier par le GHRE |  | 10d | 2026-06-01 | 2026-06-15 | 71SF | 135d |  |  |  |  |
| 68 | 2.9.1.5 | Faire déplacer le(s) véhicule(s) éventuellement stationnés ds le garage |  | 5d | 2026-06-08 | 2026-06-15 | 71SF | 135d |  |  |  |  |
| 69 | 2.9.1.6 | Dégager l'accès vers les 4 ascenseurs |  | 5d | 2026-06-08 | 2026-06-15 | 71SF | 135d |  |  |  |  |
| 70 | 2.9.2 | **Travaux** |  | 85d | 2026-06-15 | 2026-10-09 |  | 0d |  |  |  | 4095h |
| 71 | 2.9.2.1 | **Travaux réalisés par les titulaires** |  | 70d | 2026-06-15 | 2026-09-18 |  | 0d |  |  | Titulaires marchés travaux | 3920h |
| 72 | 2.9.2.1.1 | Lot n°1 : démolition / gros oeuvre |  | 70d | 2026-06-15 | 2026-09-18 | 43 | 0d |  |  | Titulaires marchés travaux | 490h |
| 73 | 2.9.2.1.2 | Lot n°2 : cloisonnement / faux plafond |  | 70d | 2026-06-15 | 2026-09-18 | 43 | 0d |  |  | Titulaires marchés travaux | 490h |
| 74 | 2.9.2.1.3 | Lot n°3 : menuiseries intérieures |  | 70d | 2026-06-15 | 2026-09-18 | 43 | 0d |  |  | Titulaires marchés travaux | 490h |
| 75 | 2.9.2.1.4 | Lot n°4 : électricité Cfa / CFO / SSI |  | 70d | 2026-06-15 | 2026-09-18 | 43 | 0d |  |  | Titulaires marchés travaux | 490h |
| 76 | 2.9.2.1.5 | Lot n°5 : plomberie / chauffage / ventilation |  | 70d | 2026-06-15 | 2026-09-18 | 43 | 0d |  |  | Titulaires marchés travaux | 490h |
| 77 | 2.9.2.1.6 | Lot n°6 : travaux de revêtements sols et murs |  | 70d | 2026-06-15 | 2026-09-18 | 43 | 0d |  |  | Titulaires marchés travaux | 490h |
| 78 | 2.9.2.1.7 | Lot n°7 : travaux de peinture / nettoyage |  | 70d | 2026-06-15 | 2026-09-18 | 43 | 0d |  |  | Titulaires marchés travaux | 490h |
| 79 | 2.9.2.2 | Nettoyage de fin de chantier |  | 1d | 2026-09-21 | 2026-09-21 | 71 | 50d | 0d |  | Titulaires marchés travaux | 7h |
| 80 | 2.9.2.3 | Réception partielle prononcée par le GHRE | milestone | 1d | 2026-09-22 | 2026-09-22 | 79 | 50d | 0d |  | RANNOU | 7h |
| 81 | 2.9.2.4 | Livraison et installation des rails leve-malade |  | 5d | 2026-09-23 | 2026-09-29 | 80 | 50d | 0d |  | Fournisseur via UGAP | 35h |
| 82 | 2.9.2.5 | Livraison et montage de 10 armoires neuves (1/2 journee de travail réel, a caler finement sur la periode ensuite) |  | 5d | 2026-09-23 | 2026-09-29 | 80 | 50d | 0d |  | Fournisseur via UGAP | 35h |
| 83 | 2.9.2.6 | Bio-nettoyage réalisé par le GHRE |  | 1d | 2026-09-30 | 2026-09-30 | 81, 82 | 50d | 0d |  | BOULO | 7h |
| 84 | 2.9.2.7 | Repose des équipements R+2 |  | 5d | 2026-10-01 | 2026-10-07 | 83 | 50d | 0d |  | PUCHER | 35h |
| 85 | 2.9.2.8 | Remettre le mobilier conservé : fauteuils, lits, chevets |  | 5d | 2026-10-01 | 2026-10-07 | 83 | 50d | 0d |  | Service Logistique | 35h |
| 86 | 2.9.2.9 | Bio-nettoyage réalisé par le GHRE |  | 1d | 2026-10-08 | 2026-10-08 | 84, 85 | 50d | 0d |  | BOULO | 7h |
| 87 | 2.9.2.10 | Zone de travaux restituée à l'EPHAD pour l'hébergement + soins | milestone | 1d | 2026-10-09 | 2026-10-09 | 86, 83 | 50d |  |  | Direction Filière Personnes Agées | 7h |
| 88 | 2.9.3 | Notification d'affermissement de la TO n°2 | milestone | 1d | 2026-08-21 | 2026-08-24 | 99SF-20d | 64d | 0d | start no earlier than 2026-08-01 | RANNOU | 7h |
| 89 | 2.9.4 | Ordre de service de démarrage TO n°2 dont 2 semaines de préparation | milestone | 1d | 2026-09-07 | 2026-09-07 | 88FS+10d | 64d | 0d |  | RANNOU | 7h |

| ID | WBS | Task | Type | Duration | Start | Finish | Predecessors | Total slack | Resources | Work |
| --- | --- | --- | --- | --- | --- | --- | --- | --- | --- | --- |
| 90 | 2.10 | **Tranche optionnelle n°2 = R+3** |  | 85d | 2026-08-24 | 2026-12-18 |  | 0d |  | 3465h |
| 91 | 2.10.1 | **Préparation des travaux** |  | 21d | 2026-08-24 | 2026-09-21 |  | 64d |  | 490h |
| 92 | 2.10.1.1 | Dépose d'équipements techniques avant travaux pour le R+3 |  | 20d | 2026-08-24 | 2026-09-21 | 99SF | 65d | PUCHER | 140h |
| 93 | 2.10.1.2 | Enlèvement du mobilier actuel et stockage en vue de la re-installation |  | 20d | 2026-08-24 | 2026-09-21 | 99SF | 65d | Service Logistique | 140h |
| 94 | 2.10.1.3 | Préparation du chantier par le titulaire |  | 10d | 2026-09-08 | 2026-09-21 | 89 | 64d | Titulaires marchés travaux | 70h |
| 95 | 2.10.1.4 | Préparation du chantier par le GHRE |  | 10d | 2026-09-07 | 2026-09-21 | 99SF | 65d | RANNOU | 70h |
| 96 | 2.10.1.5 | Faire déplacer le(s) véhicule(s) éventuellement stationnés ds le garage |  | 5d | 2026-09-14 | 2026-09-21 | 99SF | 65d | PUCHER | 35h |
| 97 | 2.10.1.6 | Dégager l'accès vers les 4 ascenseurs |  | 5d | 2026-09-14 | 2026-09-21 | 99SF | 65d | PUCHER | 35h |
| 98 | 2.10.2 | **Travaux** |  | 65d | 2026-09-21 | 2026-12-18 |  | 0d |  | 2975h |
| 99 | 2.10.2.1 | **Travaux réalisés par les titulaires** |  | 50d | 2026-09-21 | 2026-11-27 |  | 0d | Titulaires marchés travaux | 2800h |
| 100 | 2.10.2.1.1 | Lot n°1 : démolition / gros oeuvre |  | 50d | 2026-09-21 | 2026-11-27 | 71 | 0d | Titulaires marchés travaux | 350h |
| 101 | 2.10.2.1.2 | Lot n°2 : cloisonnement / faux plafond |  | 50d | 2026-09-21 | 2026-11-27 | 71 | 0d | Titulaires marchés travaux | 350h |
| 102 | 2.10.2.1.3 | Lot n°3 : menuiseries intérieures |  | 50d | 2026-09-21 | 2026-11-27 | 71 | 0d | Titulaires marchés travaux | 350h |
| 103 | 2.10.2.1.4 | Lot n°4 : électricité Cfa / CFO / SSI |  | 50d | 2026-09-21 | 2026-11-27 | 71 | 0d | Titulaires marchés travaux | 350h |
| 104 | 2.10.2.1.5 | Lot n°5 : plomberie / chauffage / ventilation |  | 50d | 2026-09-21 | 2026-11-27 | 71 | 0d | Titulaires marchés travaux | 350h |
| 105 | 2.10.2.1.6 | Lot n°6 : travaux de revêtements sols et murs |  | 50d | 2026-09-21 | 2026-11-27 | 71 | 0d | Titulaires marchés travaux | 350h |
| 106 | 2.10.2.1.7 | Lot n°7 : travaux de peinture / nettoyage |  | 50d | 2026-09-21 | 2026-11-27 | 71 | 0d | Titulaires marchés travaux | 350h |
| 107 | 2.10.2.2 | Nettoyage de fin de chantier |  | 1d | 2026-11-30 | 2026-11-30 | 99 | 0d | Titulaires marchés travaux | 7h |
| 108 | 2.10.2.3 | Réception partielle prononcée par le GHRE | milestone | 1d | 2026-12-01 | 2026-12-01 | 107 | 0d | RANNOU | 7h |
| 109 | 2.10.2.4 | Livraison et installation des rails leve-malade |  | 5d | 2026-12-02 | 2026-12-08 | 108 | 0d | Fournisseur via UGAP | 35h |
| 110 | 2.10.2.5 | Livraison et montage de 10 armoires neuves (1/2 journee de travail réel, a caler finement sur la periode ensuite) |  | 5d | 2026-12-02 | 2026-12-08 | 108 | 0d | Fournisseur via UGAP | 35h |
| 111 | 2.10.2.6 | Bio-nettoyage réalisé par le GHRE |  | 1d | 2026-12-09 | 2026-12-09 | 109, 110 | 0d | BOULO | 7h |
| 112 | 2.10.2.7 | Repose des équipements R+3 |  | 5d | 2026-12-10 | 2026-12-16 | 111 | 0d | PUCHER | 35h |
| 113 | 2.10.2.8 | Remettre le mobilier conservé : fauteuils, lits, chevets |  | 5d | 2026-12-10 | 2026-12-16 | 111 | 0d | Service Logistique | 35h |
| 114 | 2.10.2.9 | Bio-nettoyage réalisé par le GHRE |  | 1d | 2026-12-17 | 2026-12-17 | 112, 113 | 0d | BOULO | 7h |
| 115 | 2.10.2.10 | Zone de travaux restituée à l'EPHAD pour l'hébergement + soins | milestone | 1d | 2026-12-18 | 2026-12-18 | 114, 111 | 0d | Direction Filière Personnes Agées | 7h |

| ID | WBS | Task | Type | Duration | Start | Finish | Predecessors | Total slack | Resources | Work |
| --- | --- | --- | --- | --- | --- | --- | --- | --- | --- | --- |
| 116 | 2.11 | **Tranche optionnelle n°3 = Contrôle d'accès des escaliers** |  | 195d | 2026-03-23 | 2026-12-18 |  | 0d |  | 2737h |
| 117 | 2.11.1 | **Préparation des travaux** |  | 26d | 2026-03-23 | 2026-04-27 |  | 0d |  | 490h |
| 118 | 2.11.1.1 | Dépose d'équipements techniques avant travaux |  | 19d | 2026-03-31 | 2026-04-27 | 126SF | 170d | PUCHER | 133h |
| 119 | 2.11.1.2 | Préparation du chantier par le titulaire |  | 15d | 2026-03-23 | 2026-04-10 | 31SS | 0d | Titulaires marchés travaux | 105h |
| 120 | 2.11.1.3 | Préparation du chantier par le GHRE |  | 10d | 2026-04-13 | 2026-04-27 | 126SF | 170d | RANNOU | 70h |
| 121 | 2.11.1.4 | Dégager l'accès vers les escaliers |  | 5d | 2026-04-20 | 2026-04-27 | 126SF | 170d | PUCHER | 35h |
| 122 | 2.11.1.5 | PV de réception des livrables du titulaire |  | 10d | 2026-04-13 | 2026-04-24 | 119 | 0d | RANNOU; MOREAU | 140h |
| 123 | 2.11.1.6 | Ordre de service de démarrage des travaux TO n°3 | milestone | 1d | 2026-04-27 | 2026-04-27 | 122 | 0d | RANNOU | 7h |
| 124 | 2.11.2 | **Travaux** |  | 170d | 2026-04-27 | 2026-12-18 |  | 0d |  | 2247h |
| 125 | 2.11.2.1 | **Travaux réalisés par le titulaire** |  | 160d | 2026-04-27 | 2026-12-04 |  | 0d | Titulaires marchés travaux | 2240h |
| 126 | 2.11.2.1.1 | Lot n°4 : électricité Cfa / CFO / SSI |  | 160d | 2026-04-27 | 2026-12-04 | 123SS | 0d | Titulaires marchés travaux | 1120h |
| 127 | 2.11.2.2 | Nettoyage de fin de chantier |  | 1d | 2026-12-07 | 2026-12-07 | 125 | 0d | Titulaires marchés travaux | 7h |
| 128 | 2.11.2.3 | Réception partielle prononcée par le GHRE | milestone | 1d | 2026-12-08 | 2026-12-08 | 127 | 0d |  |  |
| 129 | 2.11.2.4 | Repose des équipements |  | 5d | 2026-12-09 | 2026-12-15 | 128 | 0d |  |  |
| 130 | 2.11.2.5 | Remettre le mobilier |  | 5d | 2026-12-09 | 2026-12-15 | 128 | 0d |  |  |
| 131 | 2.11.2.6 | Bio-nettoyage réalisé par le GHRE |  | 2d | 2026-12-16 | 2026-12-17 | 129, 130 | 0d |  |  |
| 132 | 2.11.2.7 | Zone de travaux restituée à l'EPHAD pour l'hébergement + soins | milestone | 1d | 2026-12-18 | 2026-12-18 | 131 | 0d |  |  |
| 133 | 2.12 | **Tranche optionnelle n°4 = Amélioration de la diffusion de l’alarme incendie** |  | 195d | 2026-03-23 | 2026-12-18 |  | 0d |  | 2352h |
| 134 | 2.12.1 | **Préparation des travaux** |  | 26d | 2026-03-23 | 2026-04-27 |  | 0d |  | 105h |
| 135 | 2.12.1.1 | Dépose d'équipements techniques avant travaux |  | 19d | 2026-03-31 | 2026-04-27 | 143SF | 170d |  |  |
| 136 | 2.12.1.2 | Préparation du chantier par le titulaire |  | 15d | 2026-03-23 | 2026-04-10 | 31SS | 0d | Titulaires marchés travaux | 105h |
| 137 | 2.12.1.3 | Préparation du chantier par le GHRE |  | 10d | 2026-04-13 | 2026-04-27 | 143SF | 170d |  |  |
| 138 | 2.12.1.4 | Dégager l'accès vers les escaliers |  | 5d | 2026-04-20 | 2026-04-27 | 126SF | 170d |  |  |
| 139 | 2.12.1.5 | PV de réception des livrables du titulaire |  | 10d | 2026-04-13 | 2026-04-24 | 136 | 0d |  |  |
| 140 | 2.12.1.6 | Ordre de service de démarrage des travaux TO n°4 | milestone | 1d | 2026-04-27 | 2026-04-27 | 139 | 0d |  |  |

| ID | WBS | Task | Type | Duration | Start | Finish | Predecessors | Total slack | Resources | Work |
| --- | --- | --- | --- | --- | --- | --- | --- | --- | --- | --- |
| 141 | 2.12.2 | **Travaux** |  | 170d | 2026-04-27 | 2026-12-18 |  | 0d |  | 2247h |
| 142 | 2.12.2.1 | **Travaux réalisés par le titulaire** |  | 160d | 2026-04-27 | 2026-12-04 |  | 0d | Titulaires marchés travaux | 2240h |
| 143 | 2.12.2.1.1 | Lot n°4 : électricité Cfa / CFO / SSI |  | 160d | 2026-04-27 | 2026-12-04 | 140SS | 0d | Titulaires marchés travaux | 1120h |
| 144 | 2.12.2.2 | Nettoyage de fin de chantier |  | 1d | 2026-12-07 | 2026-12-07 | 142 | 0d | Titulaires marchés travaux | 7h |
| 145 | 2.12.2.3 | Réception partielle prononcée par le GHRE | milestone | 1d | 2026-12-08 | 2026-12-08 | 144 | 0d |  |  |
| 146 | 2.12.2.4 | Repose des équipements |  | 5d | 2026-12-09 | 2026-12-15 | 145 | 0d |  |  |
| 147 | 2.12.2.5 | Remettre le mobilier |  | 5d | 2026-12-09 | 2026-12-15 | 145 | 0d |  |  |
| 148 | 2.12.2.6 | Bio-nettoyage réalisé par le GHRE |  | 2d | 2026-12-16 | 2026-12-17 | 146, 147 | 0d |  |  |
| 149 | 2.12.2.7 | Zone de travaux restituée à l'EPHAD pour l'hébergement + soins | milestone | 1d | 2026-12-18 | 2026-12-18 | 148 | 0d |  |  |
